# CRM-session-01-debut

Schedule from MS Project, 2019-03-04 to 2019-05-22, 7 hours a day.
Microsoft

## Calendars

- Standard: Mon-Fri 08:00-12:00, 13:00-17:00; Sat-Sun off.

## Resources

| Resource | Rate |
| --- | --- |
| Stackholder2 | 300 |
| PM1 | 150 |
| PM2 | 150 |
| Developper1 | 80 |
| Developper2 | 80 |
| Developper3 | 80 |
| Integrator1 | 100 |
| Integrator2 | 100 |
| integrator3 | 100 |
| user1 | 80 |
| user2 | 80 |
| user3 | 80 |
| user4 | 80 |
| user5 | 80 |
| Stackholder1 | 300 |
| accountant1 | 150 |
| accountant2 | 150 |
| Consulltant1 | 200 |
| Consultant2 | 200 |
| Consultant3 | 200 |
| Consultant4 | 200 |

## Schedule

| ID | WBS | Task | Type | Duration | Start | Finish | Predecessors | Total slack | Free slack | Constraint |
| --- | --- | --- | --- | --- | --- | --- | --- | --- | --- | --- |
| 1 | 01 | **CRM** |  | 66d | 2019-03-04 | 2019-05-22 |  | 0d |  |  |
| 2 | 01.01 | **Initiation** |  | 1d | 2019-03-04 | 2019-03-04 |  | 65d |  |  |
| 3 | 01.01.01 | Project proposal |  | 1d | 2019-03-04 | 2019-03-04 |  | 65d |  |  |
| 4 | 01.01.02 | Project approval | milestone | 0d | 2019-03-04 | 2019-03-04 |  | 66d |  |  |
| 5 | 01.02 | **Planning** |  | 0.5d | 2019-03-04 | 2019-03-04 |  | 65.5d |  |  |
| 6 | 1.2.1 | Planning session |  | 0.5d | 2019-03-04 | 2019-03-04 |  | 65.5d |  |  |
| 7 | 01.03 | **Execution / Realisation** |  | 55.71d | 2019-03-04 | 2019-05-09 |  | 10.29d |  |  |
| 8 | 01.03.01 | **Conception** |  | 16.5d | 2019-03-04 | 2019-03-22 |  | 29.5d |  |  |
| 9 | 01.03.01.1 | Requirements |  | 1d | 2019-03-04 | 2019-03-04 |  | 29.5d | 0d |  |
| 10 | 01.03.01.2 | Solutions evaluation |  | 2w | 2019-03-05 | 2019-03-15 | 9 | 29.5d | 0d |  |
| 11 | 01.03.01.3 | Solution choice |  | 0.5d | 2019-03-15 | 2019-03-18 | 10 | 29.5d | 0d |  |
| 12 | 01.03.01.4 | System purchase |  | 1w | 2019-03-18 | 2019-03-22 | 11 | 29.5d | 0d |  |
| 13 | 01.03.02 | **System integration** |  | 10d | 2019-03-22 | 2019-04-04 |  | 29.5d |  |  |
| 14 | 01.03.02.1 | Server installation |  | 2d | 2019-03-22 | 2019-03-26 | 12 | 29.5d | 0d |  |
| 15 | 01.03.02.2 | Application installation |  | 8d | 2019-03-26 | 2019-04-04 | 14 | 29.5d | 0d |  |
| 16 | 01.03.03 | **Test / Training** |  | 10d | 2019-04-04 | 2019-04-17 |  | 29.5d |  |  |
| 17 | 01.03.03.1 | Test UI |  | 4d | 2019-04-04 | 2019-04-09 | 15 | 29.5d | 0d |  |
| 18 | 01.03.03.2 | Functionnal test |  | 6d | 2019-04-09 | 2019-04-17 | 17 | 29.5d |  |  |
| 19 | 01.03.03.3 | Training |  | 4d | 2019-04-04 | 2019-04-09 | 15 | 35.5d |  |  |
| 20 | 01.03.04 | **Production** |  | 10d | 2019-04-29 | 2019-05-09 |  | 0d |  |  |
| 21 | 01.03.04.1 | In production | milestone | 0d | 2019-04-29 | 2019-04-29 |  | 0d |  | start no earlier than 2019-04-29 |
| 22 | 01.03.04.2 | Production run |  | 2w | 2019-04-29 | 2019-05-09 | 21 | 0d |  |  |
| 23 | 01.04 | **Project Closing** |  | 0.29d | 2019-05-22 | 2019-05-22 | 22FS+2w | 0d |  |  |
| 24 | 01.04.01 | Closing meeting |  | 2h | 2019-05-22 | 2019-05-22 |  | 0d |  |  |
